| id | name | startDate | endDate | priority | barScale | progress | type | parentId | dependencies |
| --- | --- | --- | --- | --- | --- | --- | --- | --- | --- |
| 1 | Rénovation de cuisine | 2026-06-01T00:00:00.000Z | 2026-08-10T00:00:00.000Z | medium | 1 | 0 | group |  |  |
| 2 | Valider la conception | 2026-06-01T00:00:00.000Z | 2026-06-08T00:00:00.000Z | high | 1 | 0 | task | 1 |  |
| 3 | Commander les meubles | 2026-06-08T00:00:00.000Z | 2026-06-09T00:00:00.000Z | medium | 1 | 0 | milestone | 1 | 2 FS |
| 4 | Commander les électroménagers | 2026-06-08T00:00:00.000Z | 2026-06-11T00:00:00.000Z | medium | 1 | 0 | task | 1 |  |
| 5 | Commander carrelage et sol | 2026-06-09T00:00:00.000Z | 2026-06-12T00:00:00.000Z | medium | 1 | 0 | task | 1 |  |
| 6 | Démolition | 2026-06-15T00:00:00.000Z | 2026-06-18T00:00:00.000Z | medium | 1 | 0 | task | 1 |  |
| 7 | Modifications de charpente | 2026-06-18T00:00:00.000Z | 2026-06-21T00:00:00.000Z | medium | 1 | 0 | task | 1 | 6 FS |
| 8 | Plomberie brute | 2026-06-21T00:00:00.000Z | 2026-06-24T00:00:00.000Z | medium | 1 | 0 | task | 1 | 7 FS |
| 9 | Électricité brute | 2026-06-22T00:00:00.000Z | 2026-06-25T00:00:00.000Z | medium | 1 | 0 | task | 1 | 7 FS |
| 10 | Inspection intermédiaire | 2026-06-26T00:00:00.000Z | 2026-06-27T00:00:00.000Z | medium | 1 | 0 | milestone | 1 |  |
| 11 | Plaques de plâtre | 2026-06-27T00:00:00.000Z | 2026-07-03T00:00:00.000Z | medium | 1 | 0 | task | 1 | 10 FS |
| 12 | Peinture | 2026-07-03T00:00:00.000Z | 2026-07-07T00:00:00.000Z | medium | 1 | 0 | task | 1 | 11 FS |
| 13 | Pose du sol | 2026-07-07T00:00:00.000Z | 2026-07-11T00:00:00.000Z | medium | 1 | 0 | task | 1 | 12 FS |
| 14 | Pose des meubles | 2026-07-20T00:00:00.000Z | 2026-07-23T00:00:00.000Z | medium | 1 | 0 | task | 1 | 13 FS |
| 15 | Gabarit du plan de travail | 2026-07-23T00:00:00.000Z | 2026-07-24T00:00:00.000Z | medium | 1 | 0 | milestone | 1 | 14 FS |
| 16 | Crédence | 2026-07-24T00:00:00.000Z | 2026-07-28T00:00:00.000Z | medium | 1 | 0 | task | 1 |  |
| 17 | Pose du plan de travail | 2026-07-31T00:00:00.000Z | 2026-08-01T00:00:00.000Z | medium | 1 | 0 | milestone | 1 |  |
| 18 | Pose des électroménagers | 2026-08-01T00:00:00.000Z | 2026-08-03T00:00:00.000Z | medium | 1 | 0 | task | 1 |  |
| 19 | Éléments de plomberie | 2026-08-03T00:00:00.000Z | 2026-08-05T00:00:00.000Z | medium | 1 | 0 | task | 1 |  |
| 20 | Inspection finale | 2026-08-07T00:00:00.000Z | 2026-08-08T00:00:00.000Z | medium | 1 | 0 | milestone | 1 |  |
| 21 | Liste des réserves | 2026-08-07T00:00:00.000Z | 2026-08-10T00:00:00.000Z | medium | 1 | 0 | task | 1 |  |
